| id | name | startDate | endDate | priority | barScale | progress | type | parentId | dependencies |
| --- | --- | --- | --- | --- | --- | --- | --- | --- | --- |
| 1 | Data Migration | 2026-06-01T00:00:00.000Z | 2026-09-07T00:00:00.000Z | medium | 1 | 0 | group |  |  |
| 2 | Discovery & data audit | 2026-06-01T00:00:00.000Z | 2026-06-11T00:00:00.000Z | medium | 1 | 0 | task | 1 |  |
| 3 | Define scope & success criteria | 2026-06-09T00:00:00.000Z | 2026-06-15T00:00:00.000Z | medium | 1 | 0 | task | 1 |  |
| 4 | Data mapping & field matching | 2026-06-15T00:00:00.000Z | 2026-06-28T00:00:00.000Z | high | 1 | 0 | task | 1 | 3 FS |
| 5 | Set up target environment | 2026-06-17T00:00:00.000Z | 2026-07-06T00:00:00.000Z | medium | 1 | 0 | task | 1 |  |
| 6 | Build ETL/migration scripts | 2026-06-28T00:00:00.000Z | 2026-07-16T00:00:00.000Z | high | 1 | 0 | task | 1 | 4 FS |
| 7 | Data cleansing | 2026-06-28T00:00:00.000Z | 2026-07-16T00:00:00.000Z | medium | 1 | 0 | task | 1 |  |
| 8 | Test migration in staging | 2026-07-16T00:00:00.000Z | 2026-07-28T00:00:00.000Z | medium | 1 | 0 | task | 1 | 6 FS |
| 9 | Validation & reconciliation | 2026-07-28T00:00:00.000Z | 2026-08-06T00:00:00.000Z | medium | 1 | 0 | task | 1 | 8 FS |
| 10 | User acceptance testing (UAT) | 2026-08-06T00:00:00.000Z | 2026-08-16T00:00:00.000Z | medium | 1 | 0 | task | 1 | 9 FS |
| 11 | End-user training & change management | 2026-08-08T00:00:00.000Z | 2026-08-20T00:00:00.000Z | medium | 1 | 0 | task | 1 |  |
| 12 | Cutover plan & rollback plan | 2026-08-16T00:00:00.000Z | 2026-08-23T00:00:00.000Z | high | 1 | 0 | task | 1 | 10 FS |
| 13 | Go/No-Go readiness review | 2026-08-23T00:00:00.000Z | 2026-08-24T00:00:00.000Z | high | 1 | 0 | milestone | 1 | 12 FS |
| 14 | Final legacy data freeze | 2026-08-24T00:00:00.000Z | 2026-08-25T00:00:00.000Z | medium | 1 | 0 | milestone | 1 | 13 FS |
| 15 | Go-live cutover | 2026-08-25T00:00:00.000Z | 2026-08-26T00:00:00.000Z | high | 1 | 0 | milestone | 1 | 14 FS |
| 16 | Post-migration validation | 2026-08-26T00:00:00.000Z | 2026-09-01T00:00:00.000Z | medium | 1 | 0 | task | 1 | 15 FS |
| 17 | Hypercare & monitoring | 2026-08-26T00:00:00.000Z | 2026-09-04T00:00:00.000Z | medium | 1 | 0 | task | 1 |  |
| 18 | Decommission legacy system | 2026-09-04T00:00:00.000Z | 2026-09-07T00:00:00.000Z | medium | 1 | 0 | task | 1 | 17 FS |
